# Exercise_01_2003

Schedule from MS Project, 2014-10-01 to 2014-11-27, costs in р..

## Calendars

- Стандартный: Mon-Fri 09:00-13:00, 14:00-18:00; Sat-Sun off.

## Resources

| Resource | Group | Rate |
| --- | --- | --- |
| Соловьева | ред | 500 |
| Лебедева | ред | 400 |
| Воробьева | ред | 400 |
| Воронова | ред | 400 |
| Птицына | ред | 450 |
| Зябликова | ред | 500 |
| Гусева | ред | 600 |
| Корректор |  | 300 |
| Компьютер граф |  |  |
| Спасский |  | 400 |
| Шишкин |  | 300 |
| Бумага типогр |  | 10 |
| Типография |  |  |
| Транспорт |  |  |

## Schedule

| ID | WBS | Task | Duration | Start | Finish | Predecessors | Baseline start | Baseline finish | Baseline duration | Total slack | Free slack | Resources | Work | Cost | Baseline cost | Text1 |
| --- | --- | --- | --- | --- | --- | --- | --- | --- | --- | --- | --- | --- | --- | --- | --- | --- |
| 1 | 1 | Отбор статей | 2d | 2014-10-01 | 2014-10-02 |  | 2014-10-01 | 2014-10-02 | 2d | 8.25d | 0d | Воробьева; Воронова; Гусева; Зябликова | 64h | 30,400 |  |  |
| 2 | 2 | **Редактирование** | 15d | 2014-10-03 | 2014-10-23 | 1 | 2014-10-03 | 2014-10-10 | 6d | 0d |  |  | 160h | 68,400 | 122,000 |  |
| 3 | 2.1 | Ред_Статья 1 | 3d | 2014-10-16 | 2014-10-20 |  | 2014-10-03 | 2014-10-07 | 3d | 2.62d | 0d | Воробьева | 24h | 9,600 | 9,600 | 44 |
| 4 | 2.2 | Ред_Статья 2 | 2d | 2014-10-03 | 2014-10-06 |  | 2014-10-03 | 2014-10-06 | 2d | 12.88d | 0d | Птицына | 16h | 7,200 | 7,200 | 32 |
| 5 | 2.3 | Ред_Статья 3 | 6d | 2014-10-03 | 2014-10-10 |  | 2014-10-03 | 2014-10-10 | 6d | 8.25d | 0d | Лебедева | 48h | 19,200 | 19,200 | 67 |
| 6 | 2.4 | Ред_Статья 4 | 3d | 2014-10-03 | 2014-10-07 |  | 2014-10-03 | 2014-10-07 | 3d | 11.88d | 0d | Соловьева | 24h | 12,000 | 12,000 | 35 |
| 7 | 2.5 | Ред_Статья 5 | 3d | 2014-10-21 | 2014-10-23 |  | 2014-10-03 | 2014-10-07 | 3d | 0d |  | Воробьева; Птицына | 48h | 20,400 | 20,400 | 31 |
| 8 | 3 | **Корректура** | 13.25d | 2014-10-07 | 2014-10-24 |  | 2014-10-06 | 2014-10-13 | 5.75d | 0d |  |  | 19h | 5,700 | 11,700 |  |
| 9 | 3.1 | Корр_Статья 1 | 5h | 2014-10-21 | 2014-10-21 | 3 | 2014-10-08 | 2014-10-08 | 5h | 2.62d |  | Корректор | 5h | 1,500 | 1,500 |  |
| 10 | 3.2 | Корр_Статья 2 | 3h | 2014-10-07 | 2014-10-07 | 4 | 2014-10-07 | 2014-10-07 | 3h | 12.88d |  | Корректор | 3h | 900 | 900 |  |
| 11 | 3.3 | Корр_Статья 3 | 6h | 2014-10-13 | 2014-10-14 | 5 | 2014-10-13 | 2014-10-13 | 6h | 8.12d |  | Корректор | 6h | 1,800 | 1,800 |  |
| 12 | 3.4 | Корр_Статья 4 | 3h | 2014-10-08 | 2014-10-08 | 6 | 2014-10-08 | 2014-10-08 | 3h | 11.88d |  | Корректор | 3h | 900 | 900 |  |
| 13 | 3.5 | Корр_Статья 5 | 2h | 2014-10-24 | 2014-10-24 | 7 | 2014-10-08 | 2014-10-08 | 2h | 0d |  | Корректор | 2h | 600 | 600 |  |
| 14 | 4 | Авторская коррект | 10d? | 2014-10-24 | 2014-11-07 | 8 | 2014-10-13 | 2014-10-27 | 10d? | 0d |  |  |  |  |  |  |
| 15 | 5 | Верстка | 8d | 2014-11-07 | 2014-11-19 | 14 | 2014-10-27 | 2014-11-06 | 8d | 0d |  | Компьютер граф; Спасский | 64h | 12,800 | 12,800 |  |
| 16 | 6 | Худ.оформл | 6d | 2014-11-19 | 2014-11-27 | 15 | 2014-11-06 | 2014-11-14 | 6d | 0d |  | Компьютер граф; Шишкин | 48h | 7,200 | 7,200 |  |
| 17 | 7 | Обложка | 11d | 2014-10-01 | 2014-10-15 |  | 2014-10-01 | 2014-10-15 | 11d | 30.25d | 0d | Компьютер граф; Шишкин | 100.8h | 15,840 | 15,840 |  |
